# webdev

Schedule from MS Project, 2001-11-20 to 2002-02-07, costs in $, A marks actual dates.
cdcla

## Calendars

- Standard: Mon-Fri 08:00-12:00, 13:00-17:00; Sat-Sun off.

## Resources

| Resource | Group | Rate |
| --- | --- | --- |
| Client Sponsor | Client |  |
| Own Creative Lead |  | 150 |
| Developers |  | 100 |
| Ops |  | 75 |
| Pmgr |  | 100 |
| CSR |  | 65 |
| QA |  | 75 |
| Project Manager |  | 200 |
| Sales |  |  |
| Mkt |  |  |

## Schedule

| ID | WBS | Task | Type | Duration | Start | Finish | Predecessors | Complete | Remaining | Total slack | Resources | Work | Actual work | Cost |
| --- | --- | --- | --- | --- | --- | --- | --- | --- | --- | --- | --- | --- | --- | --- |
| 1 | 1 | **1. Initiation (Inception) Phase** |  | 13d | 2001-11-20 A | 2001-12-06 |  | 6% | 12.25d | 0d |  | 120h | 6h | 4,400 |
| 2 | 1.1 | **Concept Development** |  | 8d | 2001-11-20 A | 2001-11-29 |  | 9% | 7.25d | 0d |  | 72h | 6h |  |
| 3 | 1.1.1 | Define Project Strategy |  | 2d | 2001-11-20 A | 2001-11-21 |  | 38% | 1.25d | 0d | Sales | 16h | 6h |  |
| 4 | 1.1.2 | Review |  | 1d | 2001-11-22 | 2001-11-22 | 3 |  |  | 0d | Client Sponsor; Sales | 16h |  |  |
| 5 | 1.1.3 | Storyboard use case scenario design |  | 5d | 2001-11-23 | 2001-11-29 | 4 |  |  | 0d | Client Sponsor | 40h |  |  |
| 6 | 1.1.4 | Concept approved | milestone | 0d | 2001-11-29 | 2001-11-29 | 5 |  |  | 0d | Project Manager; Client Sponsor |  |  |  |
| 7 | 1.2 | Risk Evaluation |  | 2d | 2001-11-30 | 2001-12-03 | 6 |  |  | 0d | Project Manager | 16h |  | 3,200 |
| 8 | 1.3 | Client concept review |  | 1d | 2001-12-04 | 2001-12-04 | 7 |  |  | 0d | Client Sponsor; Own Creative Lead | 16h |  | 1,200 |
| 9 | 1.4 | Finalize contract and project plan |  | 2d | 2001-12-05 | 2001-12-06 | 8 |  |  | 0d | Sales | 16h |  |  |
| 10 | 1.5 | Client acceptance | milestone | 0d | 2001-12-06 | 2001-12-06 | 9 |  |  | 0d | Client Sponsor; Project Manager |  |  |  |
| 11 | 2 | **Planning / Design (Elaboration) Phase** |  | 14d? | 2001-12-06 | 2001-12-26 |  |  |  | 0d |  | 120h |  | 11,800 |
| 12 | 2.1 | **Preproduction** |  | 3d? | 2001-12-06 | 2001-12-11 |  |  |  | 0d |  | 24h |  | 2,200 |
| 13 | 2.1.1 | Receive package | milestone | 0d | 2001-12-06 | 2001-12-06 | 10 |  |  | 0d | Project Manager |  |  |  |
| 14 | 2.1.2 | Create staging Environment |  | 1d? | 2001-12-07 | 2001-12-07 | 13 |  |  | 0d | Ops | 8h |  | 600 |
| 15 | 2.1.3 | Begin Production Guide |  | 1d? | 2001-12-10 | 2001-12-10 | 14 |  |  | 0d | Developers | 8h |  | 800 |
| 16 | 2.1.4 | Create directory structure |  | 1d? | 2001-12-11 | 2001-12-11 | 15 |  |  | 0d | Developers | 8h |  | 800 |
| 17 | 2.2 | **Production** |  | 11d? | 2001-12-11 | 2001-12-26 |  |  |  | 0d |  | 96h |  | 9,600 |
| 18 | 2.2.1 | Production package received | milestone | 0d | 2001-12-11 | 2001-12-11 | 16 |  |  | 0d | Developers |  |  |  |
| 19 | 2.2.2 | Obtain tight comps from Designer |  | 1d? | 2001-12-12 | 2001-12-12 | 18 |  |  | 0d | Developers | 8h |  | 800 |
| 20 | 2.2.3 | Add Spec info to Production Guide |  | 1d? | 2001-12-13 | 2001-12-13 | 19 |  |  | 0d | Developers | 8h |  | 800 |
| 21 | 2.2.4 | Create grid |  | 1d? | 2001-12-14 | 2001-12-14 | 20 |  |  | 0d | Developers | 8h |  | 800 |
| 22 | 2.2.5 | Cut graphics |  | 1d? | 2001-12-17 | 2001-12-17 | 21 |  |  | 0d | Developers | 8h |  | 800 |
| 23 | 2.2.6 | Create animations |  | 1d? | 2001-12-18 | 2001-12-18 | 22 |  |  | 0d | Developers | 8h |  | 800 |
| 24 | 2.2.7 | Run Environment Confirmed | milestone | 0d | 2001-12-18 | 2001-12-18 | 23 |  |  | 0d | Developers |  |  |  |
| 25 | 2.2.8 | Code HTML files |  | 4d | 2001-12-19 | 2001-12-24 | 24 |  |  | 0d | Pmgr | 32h |  | 3,200 |
| 26 | 2.2.9 | Internal Production Review |  | 1d? | 2001-12-25 | 2001-12-25 | 25 |  |  | 0d | Developers; Pmgr | 16h |  | 1,600 |
| 27 | 2.2.10 | Integration Environment |  | 1d? | 2001-12-26 | 2001-12-26 | 26 |  |  | 0d | Developers | 8h |  | 800 |

| ID | WBS | Task | Type | Duration | Start | Finish | Predecessors | Total slack | Free slack | Resources | Work | Cost |
| --- | --- | --- | --- | --- | --- | --- | --- | --- | --- | --- | --- | --- |
| 28 | 3 | **Execution (Construction) Phase** |  | 21d? | 2001-12-19 | 2002-01-16 |  | 6d |  |  | 520h | 41,600 |
| 29 | 3.1 | **Construction** |  | 13d | 2001-12-27 | 2002-01-14 |  | 0d |  |  | 104h | 10,400 |
| 30 | 3.1.1 | Bulk Programming |  | 5d | 2001-12-27 | 2002-01-02 | 27 | 0d |  | Pmgr | 40h | 4,000 |
| 31 | 3.1.2 | Handoff to Validation Testing | milestone | 0d | 2002-01-02 | 2002-01-02 | 30 | 0d |  | Developers |  |  |
| 32 | 3.1.3 | Refinement support |  | 5d | 2002-01-03 | 2002-01-09 | 30 | 18d | 0d | Pmgr | 40h | 4,000 |
| 33 | 3.1.4 | Lessons Learned Report |  | 3d | 2002-01-10 | 2002-01-14 | 32 | 18d |  | Pmgr | 24h | 2,400 |
| 34 | 3.2 | **Functionality Quality Assurance** |  | 17d? | 2001-12-19 | 2002-01-10 |  | 11d |  |  | 104h | 7,800 |
| 35 | 3.2.1 | Write QA Test Plan |  | 1d? | 2001-12-19 | 2001-12-19 | 24 | 27d | 0d | QA | 8h | 600 |
| 36 | 3.2.2 | Create QA test suites |  | 1d? | 2001-12-20 | 2001-12-20 | 35 | 27d | 0d | QA | 8h | 600 |
| 37 | 3.2.3 | Configure QA enviornment |  | 1d? | 2001-12-21 | 2001-12-21 | 36 | 27d | 0d | QA | 8h | 600 |
| 38 | 3.2.4 | Customize bug database |  | 1d? | 2001-12-24 | 2001-12-24 | 37 | 27d | 0d | QA | 8h | 600 |
| 39 | 3.2.5 | Usability Testing |  | 3d | 2001-12-25 | 2001-12-27 | 38 | 27d |  | QA | 24h | 1,800 |
| 40 | 3.2.6 | Install Handoff in QA |  | 1d? | 2002-01-03 | 2002-01-03 | 31 | 0d |  | QA | 8h | 600 |
| 41 | 3.2.7 | QA Validation Testing |  | 4d | 2002-01-04 | 2002-01-09 | 40 | 0d |  | QA | 32h | 2,400 |
| 42 | 3.2.8 | Functionality Test Signoff | milestone | 0d | 2002-01-09 | 2002-01-09 | 41 | 0d |  | QA |  |  |
| 43 | 3.2.9 | Functionality Test Report |  | 1d? | 2002-01-10 | 2002-01-10 | 42 | 20d |  | QA | 8h | 600 |
| 44 | 3.3 | **Scalability & Performance Tuning** |  | 21d | 2001-12-19 | 2002-01-16 |  | 16d |  | QA | 312h | 23,400 |
| 45 | 3.3.1 | Install in production environment |  | 2d | 2001-12-19 | 2001-12-20 | 24 | 32d |  | Ops | 16h | 1,200 |
| 46 | 3.3.2 | Test and tune performance |  | 4d | 2001-12-19 | 2001-12-24 | 24 | 25d | 0d | Ops | 32h | 2,400 |
| 47 | 3.3.3 | Obtain Performance baselines |  | 7d | 2002-01-03 | 2002-01-11 | 31 | 19d |  | Ops | 56h | 4,200 |
| 48 | 3.3.4 | Run Performance Estimates |  | 4d | 2002-01-10 | 2002-01-15 | 42 | 0d |  | Ops | 32h | 2,400 |
| 49 | 3.3.5 | Performance report |  | 1d | 2002-01-16 | 2002-01-16 | 48 | 0d |  | Ops | 8h | 600 |
| 50 | 3.4 | PreLaunch Decision | milestone | 0d | 2002-01-16 | 2002-01-16 | 49 | 0d |  | Ops; Project Manager |  |  |
| 51 | 4 | **Close-out / Transition (Launch) Phase** |  | 58d? | 2001-11-20 | 2002-02-07 |  | 0d |  |  | 368h | 34,440 |
| 52 | 4.1 | Acquire Training and Support Capabilities |  | 12d | 2001-11-20 | 2001-12-05 |  | 43d |  | Project Manager | 96h | 19,200 |
| 53 | 4.2 | Train Trainers and Support Capabilities |  | 5d | 2001-12-25 | 2001-12-31 | 46 | 25d |  | CSR | 40h | 2,600 |
| 54 | 4.3 | Internal Announcement/Promotion |  | 1d? | 2002-01-17 | 2002-01-17 | 50 | 0d |  | Project Manager | 8h | 1,600 |
| 55 | 4.4 | Delivery/notification to customer |  | 1d | 2002-01-18 | 2002-01-18 | 54 | 0d |  | CSR | 8h | 520 |
| 56 | 4.5 | User Training |  | 1d? | 2001-11-20 | 2001-11-20 |  | 54d |  | CSR | 8h | 520 |
| 57 | 4.6 | External Announcement/Publicity |  | 11d | 2002-01-18 | 2002-02-01 | 54 | 4d |  | Mkt | 88h |  |
| 58 | 4.7 | Initial Operation and Maintenance |  | 10d | 2002-01-21 | 2002-02-01 | 55 | 0d |  | Ops | 80h | 6,000 |
| 59 | 4.8 | Review Initial Webtrends stats |  | 1d? | 2002-02-04 | 2002-02-04 | 58 | 0d |  | Ops | 8h | 600 |
| 60 | 4.9 | Post-implementation analysis |  | 2d | 2002-02-05 | 2002-02-06 | 59 | 0d |  | Ops | 16h | 1,200 |
| 61 | 4.10 | Post-implementation Review meeting |  | 1d? | 2002-02-07 | 2002-02-07 | 60 | 0d |  | Ops; Project Manager | 16h | 2,200 |
